# Zmiana lokalizacji

How a schedule from MS Project changed from version to version. A marks actual dates.

## Version 1 (saved 2003-04-03, file 9_1.mpp)

| ID | WBS | Task | Duration | Start | Finish | Predecessors | Total float | Constraint |
| --- | --- | --- | --- | --- | --- | --- | --- | --- |
| 1 |  | Start | 0d | 2003-04-01 09:00 | 2003-04-01 09:00 |  | 3.5d |  |
| 2 | 2 | **Poszukiwanie lokalu** | 13.62d? | 2003-04-01 09:00 | 2003-04-18 15:00 |  | 0.5d |  |
| 3 |  | Określenie potrzeb | 1d | 2003-04-01 09:00 | 2003-04-01 18:00 | 1 | 3.5d |  |
| 4 |  | Przygotowanie ogłoszenia | 0.5d? | 2003-04-02 09:00 | 2003-04-02 13:00 | 3 | 3.5d | finish no later than 2003-04-07 18:00 |
| 5 |  | Emisja ogłoszenia | 1d | 2003-04-10 09:00 | 2003-04-10 18:00 | 4 | 0d | must start on 2003-04-10 09:00 |
| 6 | 2.4 | **Rozpatrywanie ofert** | 11.62d? | 2003-04-02 14:00 | 2003-04-18 10:00 |  | 0.5d |  |
| 7 | 2.4.1 | **Ocena ofert** | 10.62d? | 2003-04-02 14:00 | 2003-04-17 10:00 |  | 0.38d |  |
| 8 |  | Definiowanie kryteriów oceny | 0.5d | 2003-04-02 14:00 | 2003-04-02 18:00 | 4 | 6d |  |
| 9 |  | Wpisywanie zgłoszonych ofert | 1d? | 2003-04-11 09:00 | 2003-04-11 18:00 | 5, 8 | 0d |  |
| 10 |  | Wizyty w lokalach | 3d? | 2003-04-14 09:00 | 2003-04-16 18:00 | 9 | 0d |  |
| 11 |  | Przypisywanie ocen | 1d | 2003-04-16 18:00 | 2003-04-17 10:00 | 10FF | 0.5d |  |
| 12 |  | Spisanie i zebranie ocen | 1d | 2003-04-17 10:00 | 2003-04-18 10:00 | 11 | 0.5d |  |
| 13 |  | Wybór lokalu | 0d | 2003-04-18 10:00 | 2003-04-18 10:00 | 12 | 0.5d |  |
| 14 |  | Wysyłanie powiadomień o decyzji | 0.5d | 2003-04-18 10:00 | 2003-04-18 15:00 | 13 | 0.5d |  |
| 15 | 3 | **Przygotowania do przeprowadzki** | 27.83d? | 2003-04-22 09:00 | 2003-05-30 16:40 |  | 0.12d |  |
| 16 |  | Opiniowanie umowy | 2d | 2003-04-22 09:00 | 2003-04-28 13:00 | 14 | 0d |  |
| 17 |  | Podpisanie umowy | 2h | 2003-04-28 14:00 | 2003-04-28 16:00 | 16 | 0d |  |
| 18 |  | Wypowiedzenie umowy | 1h | 2003-04-28 12:00 | 2003-04-28 14:00 | 17SF | 28.15d |  |
| 19 |  | Zdanie lokalu | 0.5d? | 2003-05-30 11:40 | 2003-05-30 16:40 | 26 | 4.81d |  |
| 20 |  | Ustalenie terminu przeprowadzki | 0d? | 2003-04-28 16:00 | 2003-04-28 16:00 | 17 | 19d |  |
| 21 |  | Aranżacja wnętrz | 1mo | 2003-04-28 16:00 | 2003-05-27 16:00 | 17 | 0d |  |
| 22 | 4 | **Przeprowadzka** | 27.9d | 2003-04-28 16:00 | 2003-06-06 15:10 |  | 0d |  |
| 23 |  | Poszukiwanie środka transportu | 1d | 2003-04-28 16:00 | 2003-04-29 16:00 | 20 | 19d |  |
| 24 |  | Odebranie lokalu | 1d | 2003-05-27 16:00 | 2003-05-28 16:00 | 21, 23 | 0d |  |
| 25 |  | Pakowanie wyposażenia | 1.33d | 2003-05-28 16:00 | 2003-05-30 09:40 | 21, 24 | 0d |  |
| 26 |  | Wynoszenie wyposażenia | 2h | 2003-05-30 09:40 | 2003-05-30 11:40 | 25 | 0d |  |
| 27 |  | Załadunek | 1h | 2003-05-30 11:10 | 2003-05-30 12:10 | 26FS-2.5% | 0d |  |
| 28 |  | Transport | 0.5h | 2003-05-30 12:10 | 2003-05-30 12:40 | 27 | 0d |  |
| 29 |  | Wyładunek | 1h | 2003-05-30 12:40 | 2003-05-30 14:40 | 28 | 0d |  |
| 30 |  | Wnoszenie wyposażenia | 2h | 2003-05-30 14:10 | 2003-05-30 16:10 | 29FS-5% | 0d |  |
| 31 |  | Rozlokowanie sprzętu | 4d | 2003-05-30 14:40 | 2003-06-05 14:40 | 30FS-7.5% | 0.06d |  |
| 32 |  | Rozlokowanie wyposażenia | 4d | 2003-05-30 15:10 | 2003-06-05 15:10 | 30FS-5% | 0d |  |
| 33 |  | Sprzątanie | 1d | 2003-06-05 15:10 | 2003-06-06 15:10 | 31, 32 | 0d |  |
| 34 |  | Koniec | 0d | 2003-06-06 15:10 | 2003-06-06 15:10 | 19, 33 | 0d |  |
| 35 | 6 | **Przygotowanie raportu** | 38.25d | 2003-04-04 09:00 | 2003-05-30 11:00 |  | 5.4d |  |
| 36 |  | Przygotowanie raportu 1 | 2h | 2003-04-04 09:00 | 2003-04-04 11:00 |  | 43.4d | start no earlier than 2003-04-04 09:00 |
| 37 |  | Przygotowanie raportu 2 | 2h | 2003-04-11 09:00 | 2003-04-11 11:00 |  | 38.4d | start no earlier than 2003-04-11 09:00 |
| 38 |  | Przygotowanie raportu 3 | 2h | 2003-04-18 09:00 | 2003-04-18 11:00 |  | 33.4d | start no earlier than 2003-04-18 09:00 |
| 39 |  | Przygotowanie raportu 4 | 2h | 2003-04-25 09:00 | 2003-04-25 11:00 |  | 29.4d | start no earlier than 2003-04-25 09:00 |
| 40 |  | Przygotowanie raportu 5 | 2h | 2003-05-02 09:00 | 2003-05-02 11:00 |  | 25.4d | start no earlier than 2003-05-02 09:00 |
| 41 |  | Przygotowanie raportu 6 | 2h | 2003-05-09 09:00 | 2003-05-09 11:00 |  | 20.4d | start no earlier than 2003-05-09 09:00 |
| 42 |  | Przygotowanie raportu 7 | 2h | 2003-05-16 09:00 | 2003-05-16 11:00 |  | 15.4d | start no earlier than 2003-05-16 09:00 |
| 43 |  | Przygotowanie raportu 8 | 2h | 2003-05-23 09:00 | 2003-05-23 11:00 |  | 10.4d | start no earlier than 2003-05-23 09:00 |
| 44 |  | Przygotowanie raportu 9 | 2h | 2003-05-30 09:00 | 2003-05-30 11:00 |  | 5.4d | start no earlier than 2003-05-30 09:00 |

## Version 2 (data date 2003-04-30, saved 2003-04-03, file 9_3.mpp)

Last finish stays 2003-06-06. Complete tasks 0 → 20.

Changed:

| ID | Task | Start | Finish | Complete | Total float |
| --- | --- | --- | --- | --- | --- |
| 1 | Start | 2003-04-01 09:00 A | 2003-04-01 09:00 A | 0% → 100% | 3.5d → none |
| 2 | **Poszukiwanie lokalu** | 2003-04-01 09:00 A | 2003-04-18 15:00 A | 0% → 100% | 0.5d → none |
| 3 | Określenie potrzeb | 2003-04-01 09:00 A | 2003-04-01 18:00 A | 0% → 100% | 3.5d → none |
| 4 | Przygotowanie ogłoszenia | 2003-04-02 09:00 A | 2003-04-02 13:00 A | 0% → 100% | 3.5d → none |
| 5 | Emisja ogłoszenia | 2003-04-10 09:00 A | 2003-04-10 18:00 A | 0% → 100% | 0d → none |
| 6 | **Rozpatrywanie ofert** | 2003-04-02 14:00 A | 2003-04-18 10:00 A | 0% → 100% | 0.5d → none |
| 7 | **Ocena ofert** | 2003-04-02 14:00 A | 2003-04-17 10:00 A | 0% → 100% | 0.38d → none |
| 8 | Definiowanie kryteriów oceny | 2003-04-02 14:00 A | 2003-04-02 18:00 A | 0% → 100% | 6d → none |
| 9 | Wpisywanie zgłoszonych ofert | 2003-04-11 09:00 A | 2003-04-11 18:00 A | 0% → 100% | 0d → none |
| 10 | Wizyty w lokalach | 2003-04-14 09:00 A | 2003-04-16 18:00 A | 0% → 100% | 0d → none |
| 11 | Przypisywanie ocen | 2003-04-16 18:00 A | 2003-04-17 10:00 A | 0% → 100% | 0.5d → none |
| 12 | Spisanie i zebranie ocen | 2003-04-17 10:00 A | 2003-04-18 10:00 A | 0% → 100% | 0.5d → none |
| 13 | Wybór lokalu | 2003-04-18 10:00 A | 2003-04-18 10:00 A | 0% → 100% | 0.5d → none |
| 14 | Wysyłanie powiadomień o decyzji | 2003-04-18 10:00 A | 2003-04-18 15:00 A | 0% → 100% | 0.5d → none |
| 15 | **Przygotowania do przeprowadzki** | 2003-04-22 09:00 A |  | 0% → 16% | 0.12d → 4.81d |
| 16 | Opiniowanie umowy | 2003-04-22 09:00 A | 2003-04-28 13:00 A | 0% → 100% | 0d → none |
| 17 | Podpisanie umowy | 2003-04-28 14:00 A | 2003-04-28 16:00 A | 0% → 100% | 0d → none |
| 18 | Wypowiedzenie umowy | 2003-04-28 12:00 A | 2003-04-28 14:00 A | 0% → 100% | 28.15d → none |
| 20 | Ustalenie terminu przeprowadzki | 2003-04-28 16:00 A | 2003-04-28 16:00 → 2003-04-28 16:01 A | 0% → 100% | 19d → none |
| 21 | Aranżacja wnętrz | 2003-04-28 16:00 A |  | 0% → 6% |  |
| 22 | **Przeprowadzka** | 2003-04-28 16:00 A |  | 0% → 8% |  |
| 23 | Poszukiwanie środka transportu | 2003-04-28 16:00 A | 2003-04-29 16:00 A | 0% → 100% | 19d → none |
| 35 | **Przygotowanie raportu** | 2003-04-04 09:00 A |  | 0% → 44% |  |
| 36 | Przygotowanie raportu 1 | 2003-04-04 09:00 A | 2003-04-04 11:00 A | 0% → 100% | 43.4d → none |
| 37 | Przygotowanie raportu 2 | 2003-04-11 09:00 A | 2003-04-11 11:00 A | 0% → 100% | 38.4d → none |
| 38 | Przygotowanie raportu 3 | 2003-04-18 09:00 A | 2003-04-18 11:00 A | 0% → 100% | 33.4d → none |
| 39 | Przygotowanie raportu 4 | 2003-04-25 09:00 A | 2003-04-25 11:00 A | 0% → 100% | 29.4d → none |

## Version 3 (data date 2003-04-30, saved 2003-04-03, file 9_4.mpp)

Last finish 2003-06-06 → 2003-06-11 (+5d). Complete tasks 20 → 21.

Changed:

| ID | Task | Start | Finish | Duration | Complete | Total float |
| --- | --- | --- | --- | --- | --- | --- |
| 15 | **Przygotowania do przeprowadzki** |  | 2003-05-30 16:40 → 2003-06-05 09:40 (+6d) | 27.83d? → 31.08d? | 16% → 98% |  |
| 19 | Zdanie lokalu | 2003-05-30 11:40 → 2003-06-04 14:40 (+5d) | 2003-05-30 16:40 → 2003-06-05 09:40 (+6d) |  |  |  |
| 21 | Aranżacja wnętrz |  | 2003-05-27 16:00 → 2003-05-30 18:00 A (+3d) | 1mo → 1.16mo | 6% → 100% | 0d → none |
| 22 | **Przeprowadzka** |  | 2003-06-06 15:10 → 2003-06-11 17:10 (+5d) | 27.9d → 31.15d | 8% → 7% |  |
| 24 | Odebranie lokalu | 2003-05-27 16:00 → 2003-05-31 09:00 (+4d) | 2003-05-28 16:00 → 2003-06-02 18:00 (+5d) | 1d → 1.62d |  |  |
| 25 | Pakowanie wyposażenia | 2003-05-28 16:00 → 2003-06-03 09:00 (+6d) | 2003-05-30 09:40 → 2003-06-04 11:40 (+5d) |  |  |  |
| 26 | Wynoszenie wyposażenia | 2003-05-30 09:40 → 2003-06-04 11:40 (+5d) | 2003-05-30 11:40 → 2003-06-04 14:40 (+5d) |  |  |  |
| 27 | Załadunek | 2003-05-30 11:10 → 2003-06-04 14:10 (+5d) | 2003-05-30 12:10 → 2003-06-04 15:10 (+5d) |  |  |  |
| 28 | Transport | 2003-05-30 12:10 → 2003-06-04 15:10 (+5d) | 2003-05-30 12:40 → 2003-06-04 15:40 (+5d) |  |  |  |
| 29 | Wyładunek | 2003-05-30 12:40 → 2003-06-04 15:40 (+5d) | 2003-05-30 14:40 → 2003-06-04 16:40 (+5d) |  |  |  |
| 30 | Wnoszenie wyposażenia | 2003-05-30 14:10 → 2003-06-04 16:10 (+5d) | 2003-05-30 16:10 → 2003-06-05 09:10 (+6d) |  |  |  |
| 31 | Rozlokowanie sprzętu | 2003-05-30 14:40 → 2003-06-04 16:40 (+5d) | 2003-06-05 14:40 → 2003-06-10 16:40 (+5d) |  |  |  |
| 32 | Rozlokowanie wyposażenia | 2003-05-30 15:10 → 2003-06-04 17:10 (+5d) | 2003-06-05 15:10 → 2003-06-10 17:10 (+5d) |  |  |  |
| 33 | Sprzątanie | 2003-06-05 15:10 → 2003-06-10 17:10 (+5d) | 2003-06-06 15:10 → 2003-06-11 17:10 (+5d) |  |  |  |
| 34 | Koniec | 2003-06-06 15:10 → 2003-06-11 17:10 (+5d) | 2003-06-06 15:10 → 2003-06-11 17:10 (+5d) |  |  |  |

## Version 4 (data date 2003-04-30, saved 2003-04-03, file 9_5.mpp)

Last finish 2003-06-11 → 2003-06-12 (+1d). Complete tasks 21 → 26.

Changed:

| ID | Task | Start | Finish | Duration | Complete | Total float | Other |
| --- | --- | --- | --- | --- | --- | --- | --- |
| 15 | **Przygotowania do przeprowadzki** |  | 2003-06-05 09:40 → 2003-06-05 11:00 | 31.08d? → 31.25d? |  | 4.81d → 4.94d |  |
| 19 | Zdanie lokalu | 2003-06-04 14:40 → 2003-06-04 16:00 | 2003-06-05 09:40 → 2003-06-05 11:00 |  |  | 4.81d → 4.94d |  |
| 22 | **Przeprowadzka** |  | 2003-06-11 17:10 → 2003-06-12 10:30 (+1d) | 31.15d → 31.44d | 7% → 33% |  |  |
| 24 | Odebranie lokalu | 2003-05-31 09:00 A | 2003-06-02 18:00 A |  | 0% → 100% | 0d → none |  |
| 25 | Pakowanie wyposażenia | 2003-06-03 09:00 A | 2003-06-04 11:40 → 2003-06-04 13:00 A | 1.33d → 1.5d | 0% → 100% | 0d → none | resources Pracownik pomocniczy [300%] → Pracownik pomocniczy [266.7%] |
| 26 | Wynoszenie wyposażenia | 2003-06-04 11:40 → 2003-06-04 14:00 A | 2003-06-04 14:40 → 2003-06-04 16:00 A |  | 0% → 100% | 0d → none |  |
| 27 | Załadunek | 2003-06-04 14:10 → 2003-06-04 15:30 A | 2003-06-04 15:10 → 2003-06-04 17:00 A | 1h → 1.5h | 0% → 100% | 0d → none |  |
| 28 | Transport | 2003-06-04 15:10 → 2003-06-04 17:00 A | 2003-06-04 15:40 → 2003-06-04 18:00 A | 0.5h → 1h | 0% → 100% | 0d → none |  |
| 29 | Wyładunek | 2003-06-04 15:40 → 2003-06-05 09:00 (+1d) | 2003-06-04 16:40 → 2003-06-05 10:00 (+1d) |  |  |  |  |
| 30 | Wnoszenie wyposażenia | 2003-06-04 16:10 → 2003-06-05 09:30 (+1d) | 2003-06-05 09:10 → 2003-06-05 11:30 |  |  |  |  |
| 31 | Rozlokowanie sprzętu | 2003-06-04 16:40 → 2003-06-05 10:00 (+1d) | 2003-06-10 16:40 → 2003-06-11 10:00 (+1d) |  |  |  |  |
| 32 | Rozlokowanie wyposażenia | 2003-06-04 17:10 → 2003-06-05 10:30 (+1d) | 2003-06-10 17:10 → 2003-06-11 10:30 (+1d) |  |  |  |  |
| 33 | Sprzątanie | 2003-06-10 17:10 → 2003-06-11 10:30 (+1d) | 2003-06-11 17:10 → 2003-06-12 10:30 (+1d) |  |  |  |  |
| 34 | Koniec | 2003-06-11 17:10 → 2003-06-12 10:30 (+1d) | 2003-06-11 17:10 → 2003-06-12 10:30 (+1d) |  |  |  |  |
